# Brochure

How a schedule from MS Project changed from version to version. A marks actual dates.

## Version 1 (data date 2024-05-30, saved 2024-04-11, file 2 - Brochure Oplossing.mpp)

| ID | WBS | Task | Duration | Start | Finish | Predecessors | Total float |
| --- | --- | --- | --- | --- | --- | --- | --- |
| 1 |  | Start | 0d | 2024-04-23 | 2024-04-23 |  | 0d |
| 2 | 2 | **Tekst** | 17.5d | 2024-04-23 | 2024-05-17 |  | 0d |
| 3 |  | Vergadering | 4h | 2024-04-23 | 2024-04-23 | 1 | 0d |
| 4 |  | Schrijf tekst in FR | 5d | 2024-04-23 | 2024-04-30 | 3 | 3.5d |
| 5 |  | Reviseer tekst | 2d | 2024-04-30 | 2024-05-03 | 4 | 3.5d |
| 6 |  | Vertaal naar NL | 5d | 2024-05-06 | 2024-05-17 | 5 | 3d |
| 7 |  | Vertaal naal EN | 5d | 2024-05-06 | 2024-05-17 | 5 | 5d |
| 8 | 3 | **Logistiek** | 20d | 2024-04-23 | 2024-05-22 |  | 0d |
| 9 |  | Afbeeldingen kiezen en verzamelen | 3w | 2024-04-23 | 2024-05-15 | 3 | 0d |
| 10 |  | Naam contact op met drukkerij | 3w | 2024-04-30 | 2024-05-22 | 4 | 4d |
| 11 | 4 | **Compilatie** | 9d | 2024-05-15 | 2024-05-28 |  | 0d |
| 12 |  | Stel brochure samen in FR | 5d | 2024-05-15 | 2024-05-22 | 9, 5 | 0d |
| 13 |  | Stel brochure samen in NL | 2d | 2024-05-22 | 2024-05-24 | 12, 6 | 0d |
| 14 |  | Stel brochure samen in EN | 2d | 2024-05-24 | 2024-05-28 | 13, 7 | 0d |
| 15 | 5 | **Drukwerk** | 6.25d | 2024-05-28 | 2024-06-05 |  | 0d |
| 16 |  | Testbrochure afdrukken | 1d | 2024-05-28 | 2024-05-29 | 14, 10 | 0d |
| 17 |  | test afdrukken - meeting | 2h | 2024-05-29 | 2024-05-29 | 16 | 0d |
| 18 |  | Alle brochures afdrukken | 5d | 2024-05-29 | 2024-06-05 | 17 | 0d |
| 19 |  | Brochure beschikbaar | 0d | 2024-06-05 | 2024-06-05 | 18 | 0d |

## Version 2 (data date 2024-05-30, saved 2024-04-11, file 2 - Brochure Oplossing met tracking.mpp)

Last finish 2024-06-05 → 2024-06-07 (+2d). Complete tasks 0 → 8.

Changed:

| ID | Task | Start | Finish | Duration | Complete | Total float |
| --- | --- | --- | --- | --- | --- | --- |
| 2 | **Tekst** | 2024-04-23 A | 2024-05-17 → 2024-05-28 A (+11d) | 17.5d → 24.5d | 0% → 100% | 0d → none |
| 3 | Vergadering | 2024-04-23 A | 2024-04-23 A |  | 0% → 100% | 0d → none |
| 4 | Schrijf tekst in FR | 2024-04-23 A | 2024-04-30 → 2024-05-02 A (+2d) | 5d → 6d | 0% → 100% | 3.5d → none |
| 5 | Reviseer tekst | 2024-04-30 → 2024-05-06 A (+6d) | 2024-05-03 → 2024-05-06 A (+3d) | 2d → 1d | 0% → 100% | 3.5d → none |
| 6 | Vertaal naar NL | 2024-05-06 → 2024-05-07 A (+1d) | 2024-05-17 → 2024-05-22 A (+5d) | 5d → 6d | 0% → 100% | 3d → none |
| 7 | Vertaal naal EN | 2024-05-06 → 2024-05-07 A (+1d) | 2024-05-17 → 2024-05-28 A (+11d) | 5d → 8d | 0% → 100% | 5d → none |
| 8 | **Logistiek** | 2024-04-23 A | 2024-05-22 → 2024-05-15 A (-7d) | 20d → 15d | 0% → 100% | 0d → none |
| 9 | Afbeeldingen kiezen en verzamelen | 2024-04-23 A | 2024-05-15 A |  | 0% → 100% | 0d → none |
| 10 | Naam contact op met drukkerij | 2024-04-30 → 2024-05-02 A (+2d) | 2024-05-22 → 2024-05-06 A (-16d) | 3w → 0.4w | 0% → 100% | 4d → none |
| 11 | **Compilatie** | 2024-05-15 A | 2024-05-28 → 2024-05-30 (+2d) | 9d → 11d | 0% → 64% |  |
| 12 | Stel brochure samen in FR | 2024-05-15 A | 2024-05-22 → 2024-05-24 A (+2d) | 5d → 7d | 0% → 100% | 0d → none |
| 13 | Stel brochure samen in NL | 2024-05-22 → 2024-05-24 (+2d) | 2024-05-24 → 2024-05-28 (+4d) |  |  |  |
| 14 | Stel brochure samen in EN | 2024-05-24 → 2024-05-28 (+4d) | 2024-05-28 → 2024-05-30 (+2d) |  |  |  |
| 15 | **Drukwerk** | 2024-05-28 → 2024-05-30 (+2d) | 2024-06-05 → 2024-06-07 (+2d) |  |  |  |
| 16 | Testbrochure afdrukken | 2024-05-28 → 2024-05-30 (+2d) | 2024-05-29 → 2024-05-31 (+2d) |  |  |  |
| 17 | test afdrukken - meeting | 2024-05-29 → 2024-05-31 (+2d) | 2024-05-29 → 2024-05-31 (+2d) |  |  |  |
| 18 | Alle brochures afdrukken | 2024-05-29 → 2024-05-31 (+2d) | 2024-06-05 → 2024-06-07 (+2d) |  |  |  |
| 19 | Brochure beschikbaar | 2024-06-05 → 2024-06-07 (+2d) | 2024-06-05 → 2024-06-07 (+2d) |  |  |  |
